# SAMPLE_PROJECT

Schedule from MS Project, 2016-03-17 to 2016-06-22, costs in $.
Toshiba

## Calendars

- Standard: Mon-Fri 08:00-12:00, 13:00-17:00; Sat-Sun off.
- SAMPLE: Mon-Sat 08:00-12:00, 13:00-17:00; Sun off.

## Resources

| Resource | Unit | Rate |
| --- | --- | --- |
| ENGINEER |  | 25 |
| SUPERVISOR |  | 6.25 |
| LABOR |  | 2.5 |
| MASON |  | 3.75 |
| EXCAVATOR |  | 125 |
| TRACTOR |  | 62.5 |
| CEMENT | BAG | 15 |
| CONCRETE | CUM | 85 |
| SAND | CUM | 12 |
| BRICK | CUM | 500 |
| FOREMAN |  | 9.38 |
| AGGREGATE | CUM | 20 |
| PVC PIPES | LENGTH | 1.6 |
| CONDUITES | LENGTH | 1.5 |
| STEEL | TONN | 3000 |
| PLY BOARDS | NUMBER | 29 |
| GLASS |  | 30 |
| DOORS |  | 260 |
| ELECTRICIAN |  | 3.75 |
| PLUMBER |  | 3.75 |
| CARPENTER |  | 5 |
| BAR BINDERS |  | 5 |

## Schedule

| ID | WBS | Task | Type | Duration | Start | Finish | Predecessors | Total slack | Calendar | Resources | Work | Cost |
| --- | --- | --- | --- | --- | --- | --- | --- | --- | --- | --- | --- | --- |
| 1 | 1 | **START OF A PROJECT** |  | 73d | 2016-03-17 | 2016-06-09 |  | 0d | SAMPLE |  | 11064h | 67,785 |
| 2 | 1.1 | **PREPARING GROUND** |  | 12d | 2016-03-17 | 2016-03-30 |  | 0d | SAMPLE |  | 888h | 5,435 |
| 3 | 1.1.1 | EXCAVATION | manual | 1d | 2016-03-17 | 2016-03-17 |  |  | SAMPLE | EXCAVATOR; LABOR [200%]; TRACTOR | 32h | 1,540 |
| 4 | 1.1.2 | FOUNDATION | manual | 4d | 2016-03-18 | 2016-03-22 |  |  | SAMPLE | CONCRETE; LABOR [600%]; MASON [400%]; ENGINEER; FOREMAN; STEEL | 384h | 2,060 |
| 5 | 1.1.3 | DPC | manual | 2d | 2016-03-23 | 2016-03-24 |  |  | SAMPLE | BRICK; CEMENT; FOREMAN; LABOR; MASON [400%]; SAND; SUPERVISOR | 112h | 530 |
| 6 | 1.1.4 | LAYING OF PCC | manual | 3d | 2016-03-28 | 2016-03-30 |  |  | SAMPLE | BRICK; CONCRETE; FOREMAN; LABOR [800%]; MASON [500%]; SUPERVISOR | 360h | 1,305 |
| 7 | 1.2 | **GROUND FLOOR** |  | 20d | 2016-03-30 | 2016-04-21 |  | 0d | SAMPLE |  | 2160h | 11,515 |
| 8 | 1.2.1 | COLUMNS | manual | 7d | 2016-03-30 | 2016-04-06 |  |  | SAMPLE | STEEL; CONCRETE; ENGINEER; LABOR [300%]; MASON [200%]; PLY BOARDS; BAR BINDERS [500%] | 576h | 3,440 |
| 9 | 1.2.2 | WALLS | manual | 13d | 2016-04-07 | 2016-04-21 | 8SS |  | SAMPLE | BRICK; CEMENT; ENGINEER; FOREMAN; LABOR [600%]; MASON [400%]; SAND | 1248h | 6,695 |
| 10 | 1.2.3 | ELECT & PLUMBING | manual | 7d | 2016-04-11 | 2016-04-18 | 9SS |  | SAMPLE | CONDUITES; PVC PIPES; ELECTRICIAN [300%]; PLUMBER [200%] | 240h | 900 |
| 11 | 1.2.4 | DOORS & WINDOW FRAME | manual | 7d | 2016-04-11 | 2016-04-18 | 8SS |  | SAMPLE | DOORS; GLASS; CARPENTER [200%] | 96h | 480 |
| 12 | 1.3 | **STAIR CASE** |  | 19d | 2016-04-04 | 2016-04-25 |  | 0d | SAMPLE |  | 1024h | 8,010 |
| 13 | 1.3.1 | SHUTTERING | manual | 5d | 2016-04-04 | 2016-04-08 |  |  | SAMPLE | CARPENTER [700%]; PLY BOARDS | 280h | 1,400 |
| 14 | 1.3.2 | STEEL BINDING | manual | 6d | 2016-04-04 | 2016-04-09 |  |  | SAMPLE | BAR BINDERS [500%]; STEEL [1 TONN] | 240h | 4,200 |
| 15 | 1.3.3 | LAYING OF CONCRETE | manual | 4d | 2016-04-11 | 2016-04-14 |  |  | SAMPLE | CONCRETE; ENGINEER; LABOR [400%]; MASON [200%] | 224h | 1,360 |
| 16 | 1.3.4 | BRICK WORK FOR STEPS | manual | 7d | 2016-04-18 | 2016-04-25 |  |  | SAMPLE | BRICK; CEMENT; LABOR [200%]; MASON [200%]; SAND; SUPERVISOR | 280h | 1,050 |
| 17 | 1.4 | **ROOF** |  | 15d | 2016-04-18 | 2016-05-04 |  | 0d | SAMPLE |  | 2552h | 11,555 |
| 18 | 1.4.1 | **BEAM** |  | 6d | 2016-04-28 | 2016-05-04 |  |  | SAMPLE |  | 1400h | 6,350 |
| 19 | 1.4.1.1 | SHUTTERING | manual | 7d | 2016-04-18 | 2016-04-25 |  |  | SAMPLE | CARPENTER [700%]; LABOR [700%]; PLY BOARDS | 392h | 980 |
| 20 | 1.4.1.2 | STEEL BINDING | manual | 7d | 2016-04-18 | 2016-04-25 | 19SS |  | SAMPLE | STEEL; BAR BINDERS [1000%] | 480h | 2,400 |
| 21 | 1.4.1.3 | LAYING CONCRETE | manual | 6d | 2016-04-26 | 2016-05-02 |  |  | SAMPLE | CONCRETE; ENGINEER; FOREMAN; LABOR [500%]; MASON [400%] | 528h | 2,970 |
| 22 | 1.4.2 | **SLAB** |  | 7d | 2016-04-26 | 2016-05-04 |  | 0d |  |  | 1152h | 5,205 |
| 23 | 1.4.2.1 | SHUTTERING | manual | 7d | 2016-04-26 | 2016-05-03 |  |  | SAMPLE | CARPENTER [700%]; LABOR [400%]; PLY BOARDS | 560h | 2,240 |
| 24 | 1.4.2.2 | STEEL BINDING | manual | 7d | 2016-04-26 | 2016-05-03 | 23SS |  | SAMPLE | BAR BINDERS [1000%]; STEEL | 480h | 2,400 |
| 25 | 1.4.2.3 | LAYING CONCRETE | manual | 1d | 2016-05-04 | 2016-05-04 |  |  | SAMPLE | CONCRETE; ENGINEER; FOREMAN; LABOR [700%]; MASON [500%] | 112h | 565 |

| ID | WBS | Task | Type | Duration | Start | Finish | Total slack | Calendar | Resources | Work | Cost |
| --- | --- | --- | --- | --- | --- | --- | --- | --- | --- | --- | --- |
| 26 | 1.5 | **TOP ROOF** |  | 11d | 2016-05-11 | 2016-05-23 | 0d | SAMPLE |  | 2408h | 11,510 |
| 27 | 1.5.1 | BEAM | manual | 10d | 2016-05-11 | 2016-05-21 |  | SAMPLE | BAR BINDERS [700%]; CARPENTER [700%]; CONCRETE; LABOR [500%]; MASON [300%]; PLY BOARDS; STEEL | 1144h | 4,420 |
| 28 | 1.5.2 | SLAB | manual | 11d | 2016-05-11 | 2016-05-23 |  | SAMPLE | BAR BINDERS [500%]; CARPENTER [400%]; CONCRETE; ENGINEER; LABOR [300%]; MASON [300%]; PLY BOARDS; STEEL | 1264h | 7,090 |
| 29 | 1.6 | RAILING | manual | 4d | 2016-05-25 | 2016-05-28 |  | SAMPLE |  |  |  |
| 30 | 1.7 | BOUNDARY WALL | manual | 10d | 2016-05-30 | 2016-06-09 |  | SAMPLE | BAR BINDERS [1000%]; CARPENTER [400%]; CONCRETE; ENGINEER; EXCAVATOR; LABOR [600%]; MASON [400%]; PLY BOARDS; STEEL | 1968h | 19,440 |
| 31 | 1.8 | **FINISHING** |  | 5d | 2016-05-25 | 2016-05-30 | 0d | SAMPLE |  | 64h | 320 |
| 32 | 1.8.1 | DOORS | manual | 5d | 2016-05-25 | 2016-05-30 |  | SAMPLE | CARPENTER; DOORS | 32h | 160 |
| 33 | 1.8.2 | WINDOW GLASS | manual | 5d | 2016-05-25 | 2016-05-30 |  | SAMPLE | CARPENTER; GLASS | 32h | 160 |
| 34 | 2 | END OF PROJECT | manual | 1d | 2016-06-22 | 2016-06-22 |  | SAMPLE |  |  |  |
